# ParOsc_v4

Schedule from MS Project, 2010-07-15 to 2011-04-04, A marks actual dates.
CARA

## Calendars

- Standard: Mon-Fri 08:00-12:00, 13:00-17:00; Sat-Sun off.

## Resources

| Resource |
| --- |
| Chris Neyman |
| Kevin Tsubota |
| Sudha LaVen |
| Jon Chock |
| Olivier Martin |
| Microgate |

## Schedule

| ID | WBS | Task | Type | Duration | Start | Finish | Predecessors | Complete | Remaining | Total slack | Free slack | Resources | Work | Actual work |
| --- | --- | --- | --- | --- | --- | --- | --- | --- | --- | --- | --- | --- | --- | --- |
| 1 | 1 | **NGAO Parametric Oscillator** |  | 187.29d? | 2010-07-15 A | 2011-04-04 |  | 24% | 143.05d? | 0d |  |  | 1346h | 258.05h |
| 2 | 1.1 | **Demonstration Planning** |  | 37.5d? | 2010-07-15 A | 2010-09-06 A |  | 100% |  |  |  |  | 52h | 52h |
| 3 | 1.1.1 | Define scope |  | 5d? | 2010-07-15 A | 2010-07-21 A |  | 100% |  |  |  | Chris Neyman [20%]; Kevin Tsubota [10%] | 10h | 10h |
| 4 | 1.1.2 | Define tasks |  | 12.5d? | 2010-07-15 A | 2010-08-02 A |  | 100% |  |  |  | Chris Neyman [20%]; Kevin Tsubota [10%] | 20h | 20h |
| 5 | 1.1.3 | Schedule efforts and costs |  | 37.5d? | 2010-07-15 A | 2010-09-06 A |  | 100% |  |  |  | Kevin Tsubota [5%]; Chris Neyman [5%] | 20h | 20h |
| 6 | 1.1.4 | Engineering Change Requests (ECR) |  | 1d? | 2010-07-15 A | 2010-07-15 A |  | 100% |  |  |  | Sudha LaVen [25%] | 2h | 2h |
| 7 | 1.2 | **Preparation** |  | 19.58d? | 2010-07-15 A | 2010-08-11 |  | 65% | 6.82d? | 167.71d |  |  | 116h | 87.5h |
| 8 | 1.2.1 | Parametric Oscillator algorithm background investigation |  | 5d? | 2010-07-15 A | 2010-07-21 |  | 75% | 1.25d? | 182.29d |  | Chris Neyman [10%] | 4h | 3h |
| 9 | 1.2.2 | NGWFC architecture background investigation |  | 2d? | 2010-07-16 A | 2010-07-19 A | 6 | 100% |  |  |  | Sudha LaVen | 16h | 16h |
| 10 | 1.2.3 | Wavefront Processor (WFP) and Interface (WIF) documentation and code review |  | 2.67d? | 2010-07-20 A | 2010-07-22 | 9 | 75% | 0.67d? | 34.79d | 0d | Sudha LaVen [75%] | 16h | 12h |
| 11 | 1.2.4 | Wavefront Controller Command Processor (WCP) documentation and code review |  | 2.67d? | 2010-07-22 A | 2010-07-27 | 10 | 75% | 0.67d? | 32.79d | 0d | Sudha LaVen [75%] | 16h | 12h |
| 12 | 1.2.5 | Setup and document software development environment at Waimea HQ |  | 6.25d? | 2010-07-27 A | 2010-08-04 | 11 | 50% | 3.12d? | 29.67d | 0d | Sudha LaVen [75%]; Kevin Tsubota [10%] | 20h | 17.5h |
| 13 | 1.2.6 | Setup and document NGWFC lab hardware at Waimea HQ |  | 5d? | 2010-08-04 A | 2010-08-11 | 12 | 50% | 2.5d? | 27.17d |  | Sudha LaVen [75%]; Kevin Tsubota [10%]; Jon Chock [50%] | 44h | 27h |
| 14 | 1.3 | **Management** |  | 167d? | 2010-07-15 A | 2011-03-04 |  | 20% | 134.18d? | 20.29d |  |  | 280h | 112.55h |
| 15 | 1.3.1 | **Requirements Document** |  | 8.25d? | 2010-09-06 A | 2010-09-16 A | 2 | 100% |  |  |  |  | 48h | 48h |
| 16 | 1.3.1.1 | Write system and subsystem requirements. Documented at a level appropriate for experimental investigation not full WMKO development standards (Adkins New Instrument) |  | 6.25d? | 2010-09-06 A | 2010-09-14 A |  | 100% |  |  |  | Chris Neyman [50%]; Kevin Tsubota [40%] | 40h | 40h |
| 17 | 1.3.1.2 | Specify NGWFC external commands and status information required (ICD) |  | 1d? | 2010-09-14 A | 2010-09-15 A | 16 | 100% |  |  |  | Chris Neyman [50%] | 4h | 4h |
| 18 | 1.3.1.3 | Specify telemetry items for TRS archiving, if any |  | 1d? | 2010-09-15 A | 2010-09-16 A | 17 | 100% |  |  |  | Chris Neyman [50%] | 4h | 4h |
| 19 | 1.3.1.4 | Milestone: Requirements review | milestone | 0d? | 2010-09-09 A | 2010-09-09 A | 16, 17, 18 | 100% |  |  |  |  |  |  |
| 20 | 1.3.2 | Generate SOW |  | 10d? | 2010-09-17 A | 2010-10-01 A | 2, 7, 15 | 100% |  |  |  | Chris Neyman [50%] | 40h | 40h |
| 21 | 1.3.3 | **Writeup Contract with Microgate** |  | 9.75d? | 2010-10-01 | 2010-10-15 | 20 |  |  | 0d |  |  | 28h |  |
| 22 | 1.3.3.1 | Sole Source Justification |  | 2.5d? | 2010-10-01 | 2010-10-06 |  |  |  | 0d |  | Kevin Tsubota [40%] | 8h |  |
| 23 | 1.3.3.2 | Generate Contract |  | 6.25d? | 2010-10-06 | 2010-10-14 | 22 |  |  | 0d |  | Kevin Tsubota [40%] | 20h |  |
| 24 | 1.3.3.3 | Milestone: Contract Signed | milestone | 1d? | 2010-10-14 | 2010-10-15 | 23 |  |  | 115.79d | 0d |  |  |  |
| 25 | 1.3.4 | Ensure remote access for Microgate |  | 5d? | 2010-10-15 | 2010-10-22 | 24 |  |  | 114.79d |  | Kevin Tsubota [10%] | 4h |  |
| 26 | 1.3.5 | Oversee and direct Microgate (project long continuous task) |  | 101.5d? | 2010-10-14 | 2011-03-04 | 23 |  |  | 19.29d |  | Kevin Tsubota [7.4%] | 60h |  |
| 27 | 1.3.6 | Schedule Tracking |  | 167d? | 2010-07-15 A | 2011-03-04 |  | 25% | 126d? | 20.29d |  | Kevin Tsubota [7.5%] | 100h | 24.55h |

| ID | WBS | Task | Type | Duration | Start | Finish | Predecessors | Complete | Remaining | Total slack | Free slack | Resources | Work | Actual work |
| --- | --- | --- | --- | --- | --- | --- | --- | --- | --- | --- | --- | --- | --- | --- |
| 28 | 1.4 | **Microgate RTC Mods** |  | 44.33d? | 2010-10-14 | 2010-12-15 | 23 |  |  | 0d |  |  | 340h |  |
| 29 | 1.4.1 | NGWFC Design Document (WFP, WIF) |  | 10d? | 2010-10-14 | 2010-10-28 |  |  |  | 0d |  | Microgate | 80h |  |
| 30 | 1.4.2 | Document NGWFC Test Plan (WFP,WIF) |  | 10d? | 2010-10-28 | 2010-11-11 | 29 |  |  | 0d |  | Microgate | 80h |  |
| 31 | 1.4.3 | Implementation of WFP algorithm and Wavefront Controller Interface (WIF) modification by Microgate on HQ system (this may require reflashing?) |  | 10d? | 2010-11-11 | 2010-11-25 | 30 |  |  | 0d |  | Microgate | 80h |  |
| 32 | 1.4.4 | Microgate Testing on Waimea NGWFC system |  | 10d? | 2010-11-25 | 2010-12-09 | 31 |  |  | 0d |  | Microgate | 80h |  |
| 33 | 1.4.5 | WMKO run tests based on MG test plan |  | 3.33d? | 2010-12-09 | 2010-12-14 | 32 |  |  | 0d |  | Sudha LaVen [75%] | 20h |  |
| 34 | 1.4.6 | Milestone: WMKO acceptance of Microgate mods | milestone | 1d? | 2010-12-14 | 2010-12-15 | 33 |  |  | 0d |  |  |  |  |
| 35 | 1.5 | **Systems Engineering / Design** |  | 39.83d? | 2010-10-01 A | 2010-11-26 | 20 | 3% | 38.63d? | 6.58d |  |  | 188h | 6h |
| 36 | 1.5.1 | **Design Parametric Oscillator Algorithm** |  | 17d? | 2010-10-01 A | 2010-10-26 |  | 9% | 15.5d? | 6.58d | 0d |  | 68h | 6h |
| 37 | 1.5.1.1 | Determine "as built" STRAP, DTT, and WFP control loop parameters for Keck AO system |  | 1d? | 2010-10-01 A | 2010-10-04 |  | 50% | 0.5d? | 7.58d | 0d | Chris Neyman [50%] | 4h | 2h |
| 38 | 1.5.1.2 | Investigate parametric oscillator algorithm used for IF |  | 2d? | 2010-10-04 A | 2010-10-06 | 37 | 50% | 1d? | 6.58d | 0d | Chris Neyman [50%] | 8h | 4h |
| 39 | 1.5.1.3 | Modify KAON 680 Simulink simulation |  | 4d? | 2010-10-06 | 2010-10-12 | 38 |  |  | 6.58d | 0d | Chris Neyman [50%] | 16h |  |
| 40 | 1.5.1.4 | Write Par. Osc. Algorithm Design Document |  | 6d? | 2010-10-12 | 2010-10-20 | 39 |  |  | 6.58d | 0d | Chris Neyman [50%] | 24h |  |
| 41 | 1.5.1.5 | Provide algorithm outline and direction to software team |  | 4d? | 2010-10-20 | 2010-10-26 | 40 |  |  | 6.58d |  | Chris Neyman [50%] | 16h |  |
| 42 | 1.5.2 | **Software Design Document** |  | 13.5d? | 2010-10-26 | 2010-11-15 | 36 |  |  | 6.58d | 0d |  | 80h |  |
| 43 | 1.5.2.1 | AO Design Document (WCP) |  | 6.67d? | 2010-10-26 | 2010-11-04 |  |  |  | 9.08d | 0d | Sudha LaVen [75%] | 40h |  |
| 44 | 1.5.2.2 | Design modification to AO User Tools (if required) |  | 12.5d? | 2010-10-26 | 2010-11-12 |  |  |  | 6.58d | 0d | Olivier Martin [20%] | 20h |  |
| 45 | 1.5.2.3 | Design modification to AO SC (if required) |  | 3.33d? | 2010-11-04 | 2010-11-09 | 43 |  |  | 9.08d | 2.5d | Sudha LaVen [75%] | 20h |  |
| 46 | 1.5.2.4 | Milestone: Design review | milestone | 1d? | 2010-11-12 | 2010-11-15 | 43, 44, 45 |  |  | 6.58d |  |  |  |  |
| 47 | 1.5.3 | **Software Test Plan** |  | 9.33d? | 2010-11-15 | 2010-11-26 | 42 |  |  | 6.58d | 0d |  | 40h |  |
| 48 | 1.5.3.1 | Document AO Test Plan (WCP) |  | 3.33d? | 2010-11-15 | 2010-11-18 |  |  |  | 6.58d | 0d | Sudha LaVen [75%] | 20h |  |
| 49 | 1.5.3.2 | Document System Level Summit Integration Test Plan |  | 5d? | 2010-11-18 | 2010-11-25 | 48 |  |  | 6.58d | 0d | Chris Neyman [50%] | 20h |  |
| 50 | 1.5.3.3 | Milestone: Test plan review | milestone | 1d? | 2010-11-25 | 2010-11-26 | 48, 49 |  |  | 6.58d |  |  |  |  |
| 51 | 1.6 | **Implementation and Lab Testing** |  | 48d? | 2010-11-26 | 2011-02-02 | 42, 47 |  |  | 0d |  |  | 180h |  |
| 52 | 1.6.1 | **Wavefront Control Command Processor (WCP)** |  | 16.58d? | 2010-11-26 | 2010-12-21 |  |  |  | 0d |  |  | 60h |  |
| 53 | 1.6.1.1 | Implementation of AO (WCP) modifications |  | 6.67d? | 2010-11-26 | 2010-12-07 |  |  |  | 6.58d |  | Sudha LaVen [75%] | 40h |  |
| 54 | 1.6.1.2 | Testing on Waimea NGWFC system |  | 3.33d? | 2010-12-15 | 2010-12-21 | 53, 34 |  |  | 0d |  | Sudha LaVen [75%] | 20h |  |

| ID | WBS | Task | Type | Duration | Start | Finish | Predecessors | Total slack | Resources | Work |
| --- | --- | --- | --- | --- | --- | --- | --- | --- | --- | --- |
| 55 | 1.6.2 | **AO User Tools** |  | 18.75d? | 2010-12-21 | 2011-01-14 | 52 | 0d |  | 30h |
| 56 | 1.6.2.1 | Implementation of AO User Tools (IDL tools) modifications |  | 12.5d? | 2010-12-21 | 2011-01-06 |  | 0d | Olivier Martin [20%] | 20h |
| 57 | 1.6.2.2 | Testing on Waimea NGWFC system |  | 6.25d? | 2011-01-06 | 2011-01-14 | 56 | 0d | Olivier Martin [20%] | 10h |
| 58 | 1.6.3 | **AO SC** |  | 5d? | 2011-01-14 | 2011-01-21 | 55 | 0d |  | 30h |
| 59 | 1.6.3.1 | Implementation of AO SC modification by WMKO on HQ system |  | 3.33d? | 2011-01-14 | 2011-01-20 |  | 0d | Sudha LaVen [75%] | 20h |
| 60 | 1.6.3.2 | Testing on Waimea NGWFC system |  | 1.67d? | 2011-01-20 | 2011-01-21 | 59 | 0d | Sudha LaVen [75%] | 10h |
| 61 | 1.6.4 | **Lab Integration** |  | 7.67d? | 2011-01-21 | 2011-02-02 |  | 0d |  | 60h |
| 62 | 1.6.4.1 | Perform and document lab integration tests |  | 6.67d? | 2011-01-21 | 2011-02-01 | 60 | 0d | Sudha LaVen [75%]; Chris Neyman [40%] | 60h |
| 63 | 1.6.4.2 | Milestone: Lab integration complete | milestone | 1d? | 2011-02-01 | 2011-02-02 | 62 | 0d |  |  |
| 64 | 1.7 | **Summit Integration** |  | 10.33d? | 2011-02-02 | 2011-02-16 | 51 | 0d |  | 62h |
| 65 | 1.7.1 | **NGWFC** |  | 4.67d? | 2011-02-02 | 2011-02-09 |  | 0d |  | 28h |
| 66 | 1.7.1.1 | Install upgrade on summit system |  | 1.33d? | 2011-02-02 | 2011-02-03 |  | 0d | Sudha LaVen [75%] | 8h |
| 67 | 1.7.1.2 | Run same Microgate test plan used for HQ testing |  | 3.33d? | 2011-02-03 | 2011-02-09 | 66 | 0d | Sudha LaVen [75%] | 20h |
| 68 | 1.7.2 | **AO** |  | 2.33d? | 2011-02-09 | 2011-02-11 | 65 | 0d |  | 14h |
| 69 | 1.7.2.1 | Install upgrade on summit system |  | 0.67d? | 2011-02-09 | 2011-02-09 |  | 0d | Sudha LaVen [75%] | 4h |
| 70 | 1.7.2.2 | Run same test plan used for HQ testing |  | 1.67d? | 2011-02-09 | 2011-02-11 | 69 | 0d | Sudha LaVen [75%] | 10h |
| 71 | 1.7.3 | **System Integration** |  | 3.33d? | 2011-02-11 | 2011-02-16 | 68 | 0d |  | 20h |
| 72 | 1.7.3.1 | Run system level summit integration test plan |  | 3.33d? | 2011-02-11 | 2011-02-16 |  | 0d | Sudha LaVen [75%] | 20h |
| 73 | 1.8 | **Parametric Oscillator Demonstration** |  | 23d? | 2011-02-16 | 2011-03-21 | 64 | 0d |  | 88h |
| 74 | 1.8.1 | **Observing Plan** |  | 2d? | 2011-02-16 | 2011-02-18 |  | 0d |  | 8h |
| 75 | 1.8.1.1 | Plan nighttime observations with Parametric Oscillator |  | 2d? | 2011-02-16 | 2011-02-18 |  | 0d | Chris Neyman [50%] | 8h |
| 76 | 1.8.2 | **Observation** |  | 6d? | 2011-02-18 | 2011-02-28 | 74 | 0d |  | 24h |
| 77 | 1.8.2.1 | Nighttime testing of Par. Osc. modification |  | 6d? | 2011-02-18 | 2011-02-28 |  | 0d | Chris Neyman [50%] | 24h |
| 78 | 1.8.3 | **Demonstration Report** |  | 15d? | 2011-02-28 | 2011-03-21 | 76 | 0d |  | 56h |
| 79 | 1.8.3.1 | Analysis of test data |  | 10d? | 2011-02-28 | 2011-03-14 |  | 0d | Chris Neyman [50%] | 40h |
| 80 | 1.8.3.2 | Write demonstration test report |  | 4d? | 2011-03-14 | 2011-03-18 | 79 | 0d | Chris Neyman [50%] | 16h |
| 81 | 1.8.3.3 | Milestone: Recommendation on implementation (Section of final report hours part of above task) | milestone | 1d? | 2011-03-18 | 2011-03-21 | 80 | 0d |  |  |

| ID | WBS | Task | Duration | Start | Finish | Predecessors | Total slack | Resources | Work |
| --- | --- | --- | --- | --- | --- | --- | --- | --- | --- |
| 82 | 1.9 | **Remaining Implementation Plan for Parametric Oscillator** | 9.38d? | 2011-03-21 | 2011-04-04 | 73 | 0d |  | 40h |
| 83 | 1.9.1 | Define tasks and effort remaining for implementation | 3.12d? | 2011-03-21 | 2011-03-25 |  | 0d | Chris Neyman [50%]; Kevin Tsubota [40%] | 20h |
| 84 | 1.9.2 | Schedule efforts and cost | 6.25d? | 2011-03-25 | 2011-04-04 | 83 | 0d | Kevin Tsubota [40%] | 20h |
